# Construcción de vivienda

Schedule from MS Project, 2024-05-02 to 2024-11-04, 10 hours a day, costs in $.
1era etapa

## Calendars

- VR1: Mon-Fri 07:00-17:00; Sat 06:00-12:00; Sun off. Exceptions (off unless hours are given): 2024-05-24 (n1), 2024-06-03 (n2), 2024-08-01 (n3), 2024-08-12 (n4).
- VR2: Mon-Fri 08:00-16:00; Sat-Sun off.

## Resources

| Resource | Unit | Rate |
| --- | --- | --- |
| Director de proyecto |  | 70 |
| Asistente DP |  | 30 |
| Ingeniero civil |  | 40 |
| Arquitecto |  | 35 |
| Cuadrilla de Obreros |  | 5 |
| Técnico Eléctrico |  | 40 |
| Ayudante |  | 4 |
| Plomero |  | 25 |
| Pintor |  | 8 |
| Concreto | m3 | 1627 |
| Vigas de amarre | m3 | 4655 |
| Ladrillo | m2 | 47 |
| Losa maciza | m2 | 62 |
| Escaleras | m3 | 693 |
| Teja española | m2 | 34 |
| Contrapiso | m2 | 120 |
| Placa | m2 | 585 |
| Repello | m2 | 6 |
| Pintura | m2 | 29 |
| Enchape | m2 | 50 |
| Porcelanato | m2 | 30 |
| Marcos de puertas | Un | 136 |
| Puerta principales | Un | 250 |
| Ventanas | m2 | 80 |
| Puertas interiores | Un | 120 |
| Closet | m2 | 700 |
| Cerraduras principales | Un | 250 |
| Cerraduras interiores | Un | 70 |
| Vidrios | m2 | 231 |
| Acometida hidráulica | Un | 120 |
| Tanque de agua | Un | 200 |
| Lavadero | Un | 471 |
| Sanitario | Un | 191 |
| Ducha | Un | 187 |
| Acometida eléctrica | ml | 462 |
| Tablero 4 circuitos | Un | 380 |
| Lámpara | Un | 627 |
| Tomas y salida PVC | Un | 117 |
| Limpieza y bodega |  |  |
| Excavación |  |  |
| Instalación hidráulica |  |  |
| Aseo |  |  |
| Carpintero |  | 8 |
| Traslado |  |  |

## Schedule

| ID | WBS | Task | Duration | Start | Finish | Predecessors | Baseline start | Baseline finish | Baseline duration | Baseline 1 start | Baseline 1 finish | Total slack | Free slack | Calendar | Resources | Work | Cost | Baseline cost |
| --- | --- | --- | --- | --- | --- | --- | --- | --- | --- | --- | --- | --- | --- | --- | --- | --- | --- | --- |
| 1 | 1 | **Casa modelo** | 76.2d | 2024-05-02 | 2024-08-08 |  | 2017-05-02 | 2017-08-11 | 79.2d | 2017-05-02 | 2017-08-10 | 0d |  |  |  | 1284h | 94,832.5 | 94,832.5 |
| 2 | 1.1 | **Preliminares** | 22.2d | 2024-05-02 | 2024-05-30 |  | 2017-05-02 | 2017-06-05 | 25.2d | 2017-05-02 | 2017-06-05 | 0d |  |  |  | 232h | 8,858 | 8,858 |
| 3 | 1.1.1 | **Localización y replanteo** | 19d | 2024-05-02 | 2024-05-27 |  | 2017-05-02 | 2017-05-30 | 22d | 2017-05-02 | 2017-05-30 | 0d |  |  |  | 200h | 8,730 | 8,730 |
| 4 | 1.1.1.1 | Verificar permisos | 1.43w | 2024-05-02 | 2024-05-15 |  | 2017-05-02 | 2017-05-15 | 1.43w | 2017-05-02 | 2017-05-15 | -2.4d | 0d | VR2 | Asistente DP | 80h | 2,400 | 2,400 |
| 5 | 1.1.1.2 | Verificar planos constructivos en sitio | 0.71w | 2024-05-16 | 2024-05-22 | 4 | 2017-05-19 | 2017-05-26 | 0.71w | 2017-05-19 | 2017-05-26 | -2.4d | 0d | VR2 | Arquitecto; Director de proyecto; Ingeniero civil; Traslado [0.1%] | 120h | 5,870 | 5,870 |
| 6 | 1.1.1.3 | Colocar bodega | 2.4d | 2024-05-22 | 2024-05-27 | 5 | 2017-05-26 | 2017-05-30 | 2.4d | 2017-05-26 | 2017-05-30 | -3.1d | 0d |  | Limpieza y bodega [0.1%] |  | 460 | 460 |
| 7 | 1.1.2 | **Limpieza** | 3.2d | 2024-05-27 | 2024-05-30 |  | 2017-05-30 | 2017-06-05 | 3.2d | 2017-05-30 | 2017-06-05 | 0d |  |  |  | 32h | 128 | 128 |
| 8 | 1.1.2.1 | Nivelar terreno | 1.6d | 2024-05-27 | 2024-05-29 | 6 | 2017-05-30 | 2017-06-02 | 1.6d | 2017-05-30 | 2017-06-02 | -3.1d | 0d |  | Ayudante | 16h | 64 | 64 |
| 9 | 1.1.2.2 | Limpiar terreno | 1.6d | 2024-05-29 | 2024-05-30 | 8 | 2017-06-02 | 2017-06-05 | 1.6d | 2017-06-02 | 2017-06-05 | -3.1d | 0d |  | Ayudante | 16h | 64 | 64 |
| 10 | 1.2 | **Construcción** | 40d | 2024-05-30 | 2024-07-22 |  | 2017-06-05 | 2017-07-25 | 40d | 2017-06-05 | 2017-07-22 | 0d |  |  |  | 940h | 81,454.5 | 81,454.5 |
| 11 | 1.2.1 | **Cimentación** | 6.4d | 2024-05-30 | 2024-06-10 |  | 2017-06-05 | 2017-06-13 | 6.4d | 2017-06-05 | 2017-06-13 | 0d |  |  |  | 96h | 23,753 | 23,753 |
| 12 | 1.2.1.1 | Realizar excavación | 1.6d | 2024-05-30 | 2024-06-01 | 9 | 2017-06-05 | 2017-06-06 | 1.6d | 2017-06-05 | 2017-06-06 | -3.1d | 0d |  | Excavación [0.1%] |  | 963 | 963 |
| 13 | 1.2.1.2 | Colocar concreto | 1.6d | 2024-06-01 | 2024-06-05 | 12 | 2017-06-06 | 2017-06-08 | 1.6d | 2017-06-06 | 2017-06-08 | -3.1d | 0d |  | Ayudante; Concreto [8 m3]; Cuadrilla de Obreros [400%] | 32h | 13,160 | 13,160 |
| 14 | 1.2.1.3 | Colocar vigas de amarre | 3.2d | 2024-06-05 | 2024-06-10 | 13 | 2017-06-08 | 2017-06-13 | 3.2d | 2017-06-08 | 2017-06-13 | -3.1d | 0d |  | Cuadrilla de Obreros [200%]; Vigas de amarre [2 m3] | 64h | 9,630 | 9,630 |
| 15 | 1.2.2 | **Estructura** | 16d | 2024-06-10 | 2024-06-28 |  | 2017-06-13 | 2017-07-03 | 16d | 2017-06-13 | 2017-07-03 | 0d |  |  |  | 368h | 20,722.5 | 20,722.5 |
| 16 | 1.2.2.1 | **Realizar muro estructural** | 7.2d | 2024-06-10 | 2024-06-18 |  | 2017-06-13 | 2017-06-21 | 7.2d | 2017-06-13 | 2017-06-21 | 0d |  |  |  | 144h | 6,606 | 6,606 |
| 17 | 1.2.2.1.1 | Realizar en 1era planta | 3.2d | 2024-06-10 | 2024-06-13 | 14 | 2017-06-13 | 2017-06-16 | 3.2d | 2017-06-13 | 2017-06-16 | -3.1d | 0d |  | Ladrillo [100 m2]; Ayudante; Cuadrilla de Obreros [200%] | 64h | 4,988 | 4,988 |
| 18 | 1.2.2.1.2 | Realizar en cubierta | 4d | 2024-06-13 | 2024-06-18 | 17 | 2017-06-16 | 2017-06-21 | 4d | 2017-06-16 | 2017-06-21 | -3.1d | 0d |  | Ayudante; Cuadrilla de Obreros [200%]; Teja española [37 m2] | 80h | 1,618 | 1,618 |
| 19 | 1.2.2.2 | Colocar losa de entrepiso | 4d | 2024-06-18 | 2024-06-24 | 18 | 2017-06-21 | 2017-06-27 | 4d | 2017-06-21 | 2017-06-27 | -3.1d | 0d |  | Ayudante; Losa maciza [31 m2]; Cuadrilla de Obreros [300%] | 120h | 2,482 | 2,482 |
| 20 | 1.2.2.3 | Realizar escalera | 3.2d | 2024-06-24 | 2024-06-27 | 19 | 2017-06-27 | 2017-06-30 | 3.2d | 2017-06-27 | 2017-06-30 | -3.1d | 0d |  | Escaleras [1 m3]; Cuadrilla de Obreros | 32h | 853 | 853 |
| 21 | 1.2.2.4 | Colocar cubierta | 4d | 2024-06-18 | 2024-06-24 | 18 | 2017-06-21 | 2017-06-27 | 4d | 2017-06-21 | 2017-06-27 | 1.7d |  |  | Cuadrilla de Obreros; Ladrillo [120 m2] | 40h | 5,840 | 5,840 |
| 22 | 1.2.2.5 | Chorrear contra-piso | 1.6d | 2024-06-27 | 2024-06-28 | 19, 20 | 2017-06-30 | 2017-07-03 | 1.6d | 2017-06-30 | 2017-07-03 | -3.1d | 0d |  | Contrapiso [30 m2] |  | 3,600 | 3,600 |
| 23 | 1.2.2.6 | Realizar placa del tanque de agua | 1.6d | 2024-06-18 | 2024-06-20 | 18 | 2017-06-21 | 2017-06-23 | 1.6d | 2017-06-21 | 2017-06-23 | 20.9d | 0d |  | Ayudante; Plomero; Placa [1.5 m2] | 32h | 1,341.5 | 1,341.5 |
| 24 | 1.2.3 | **Acabados** | 9.2d | 2024-06-28 | 2024-07-10 |  | 2017-07-03 | 2017-07-13 | 9.2d | 2017-07-03 | 2017-07-13 | 0d |  |  |  | 344h | 13,612 | 13,612 |
| 25 | 1.2.3.1 | **Colocar mampostería estructural** | 8.4d | 2024-06-28 | 2024-07-10 |  | 2017-07-03 | 2017-07-13 | 8.4d | 2017-07-03 | 2017-07-11 | 0d |  |  |  | 104h | 3,934 | 3,934 |
| 26 | 1.2.3.1.1 | Colocar repello | 1.2d | 2024-06-28 | 2024-07-01 | 21, 22 | 2017-07-03 | 2017-07-04 | 1.2d | 2017-07-03 | 2017-07-04 | -3.1d | 0d |  | Cuadrilla de Obreros [200%]; Ayudante; Repello [400 m2] | 32h | 2,552 | 2,552 |
| 27 | 1.2.3.1.2 | Afinar filos | 1.6d | 2024-07-01 | 2024-07-03 | 26 | 2017-07-04 | 2017-07-06 | 1.6d | 2017-07-04 | 2017-07-06 | -3.1d | 0d |  | Ayudante | 16h | 64 | 64 |
| 28 | 1.2.3.1.3 | Aplicar pintura | 1w | 2024-07-03 | 2024-07-10 | 27 | 2017-07-06 | 2017-07-13 | 1w | 2017-07-06 | 2017-07-11 | -3.1d | 0d |  | Pintor; Pintura [30 m2] | 56h | 1,318 | 1,318 |

| ID | WBS | Task | Duration | Start | Finish | Predecessors | Baseline start | Baseline finish | Baseline duration | Baseline 1 start | Baseline 1 finish | Total slack | Free slack | Resources | Work | Cost | Baseline cost |
| --- | --- | --- | --- | --- | --- | --- | --- | --- | --- | --- | --- | --- | --- | --- | --- | --- | --- |
| 29 | 1.2.3.2 | **Colocar pisos y enchapes** | 8d | 2024-07-01 | 2024-07-10 |  | 2017-07-04 | 2017-07-13 | 8d | 2017-07-04 | 2017-07-13 | 11.6d |  |  | 56h | 2,348 | 2,348 |
| 30 | 1.2.3.2.1 | Colocar enchape baño | 0.8d | 2024-07-01 | 2024-07-02 | 26 | 2017-07-04 | 2017-07-05 | 0.8d | 2017-07-04 | 2017-07-05 | 27.3d |  | Pintor; Enchape [4 m2] | 8h | 264 | 264 |
| 31 | 1.2.3.2.2 | Alistar piso | 1.6d | 2024-07-04 | 2024-07-06 | 28SS+1.6d | 2017-07-07 | 2017-07-10 | 1.6d | 2017-07-07 | 2017-07-10 | 5.3d | 0d | Ayudante | 16h | 64 | 64 |
| 32 | 1.2.3.2.3 | Instalar piso | 3.2d | 2024-07-06 | 2024-07-10 | 31 | 2017-07-10 | 2017-07-13 | 3.2d | 2017-07-10 | 2017-07-13 | 5.3d |  | Cuadrilla de Obreros; Porcelanato [62 m2] | 32h | 2,020 | 2,020 |
| 33 | 1.2.3.3 | **Instalar piso** | 8d | 2024-07-01 | 2024-07-10 |  | 2017-07-04 | 2017-07-13 | 8d | 2017-07-04 | 2017-07-13 | 8.4d |  |  | 136h | 5,370 | 5,370 |
| 34 | 1.2.3.3.1 | **Realizar estructura metálica** | 2.4d | 2024-07-01 | 2024-07-03 |  | 2017-07-04 | 2017-07-06 | 2.4d | 2017-07-04 | 2017-07-06 | 8.4d |  |  | 48h | 1,578 | 1,578 |
| 35 | 1.2.3.3.1.1 | Armar marcos de puertas | 1.6d | 2024-07-01 | 2024-07-03 | 26 | 2017-07-04 | 2017-07-06 | 1.6d | 2017-07-04 | 2017-07-06 | 24.9d | 0d | Carpintero; Marcos de puertas [6 Un] | 16h | 944 | 944 |
| 36 | 1.2.3.3.1.2 | Colocar puerta entrada y patio | 0.8d | 2024-07-03 | 2024-07-03 | 35 | 2017-07-06 | 2017-07-06 | 0.8d | 2017-07-06 | 2017-07-06 | 24.9d | 0d | Carpintero; Puerta principales [1 Un] | 8h | 314 | 314 |
| 37 | 1.2.3.3.1.3 | Armar ventanas | 2.4d | 2024-07-01 | 2024-07-03 | 26 | 2017-07-04 | 2017-07-06 | 2.4d | 2017-07-04 | 2017-07-06 | 5.3d | 0d | Cuadrilla de Obreros; Ventanas [2.5 m2] | 24h | 320 | 320 |
| 38 | 1.2.3.3.2 | **Realizar estructura madera** | 6.4d | 2024-07-03 | 2024-07-10 |  | 2017-07-06 | 2017-07-13 | 6.4d | 2017-07-06 | 2017-07-13 | 10.8d |  |  | 88h | 3,792 | 3,792 |
| 39 | 1.2.3.3.2.1 | Colocar puerta de interiores | 0.8d | 2024-07-03 | 2024-07-03 | 35 | 2017-07-06 | 2017-07-06 | 0.8d | 2017-07-06 | 2017-07-06 | 24.9d | 0d | Ayudante; Puertas interiores [4 Un] | 8h | 512 | 512 |
| 40 | 1.2.3.3.2.2 | Armar closet | 0.71w | 2024-07-05 | 2024-07-10 | 37FS+1.6d | 2017-07-08 | 2017-07-13 | 0.71w | 2017-07-08 | 2017-07-13 | 5.3d |  | Ayudante; Carpintero; Closet [4 m2] | 80h | 3,280 | 3,280 |
| 41 | 1.2.3.4 | **Colocar vidrios y cerraduras** | 3.2d | 2024-07-03 | 2024-07-08 |  | 2017-07-06 | 2017-07-11 | 3.2d | 2017-07-06 | 2017-07-11 | 10.8d |  |  | 48h | 1,960 | 1,960 |
| 42 | 1.2.3.4.1 | Colocar cerradura de entrada y patio | 0.8d | 2024-07-03 | 2024-07-04 | 36 | 2017-07-06 | 2017-07-07 | 0.8d | 2017-07-06 | 2017-07-07 | 24.9d |  | Cerraduras principales [2 Un]; Carpintero | 8h | 564 | 564 |
| 43 | 1.2.3.4.2 | Colocar cerradura de puertas interiores | 0.8d | 2024-07-03 | 2024-07-04 | 36, 39 | 2017-07-06 | 2017-07-07 | 0.8d | 2017-07-06 | 2017-07-07 | 24.9d |  | Ayudante; Cerraduras interiores [4 Un] | 8h | 312 | 312 |
| 44 | 1.2.3.4.3 | Colocar vidrios | 3.2d | 2024-07-03 | 2024-07-08 | 37 | 2017-07-06 | 2017-07-11 | 3.2d | 2017-07-06 | 2017-07-11 | 7.7d |  | Cuadrilla de Obreros; Vidrios [4 m2] | 32h | 1,084 | 1,084 |
| 45 | 1.2.4 | **Instalaciones domiciliarias** | 30.4d | 2024-06-13 | 2024-07-22 |  | 2017-06-16 | 2017-07-25 | 30.4d | 2017-06-16 | 2017-07-22 | 0d |  |  | 132h | 23,367 | 23,367 |
| 46 | 1.2.4.1 | **Realizar instalaciones hidrosanitarias** | 25.2d | 2024-06-13 | 2024-07-15 |  | 2017-06-16 | 2017-07-18 | 25.2d | 2017-06-16 | 2017-07-15 | 5.2d |  |  | 40h | 4,001 | 4,001 |
| 47 | 1.2.4.1.1 | Realizar acometida hidráulica | 0.8d | 2024-06-13 | 2024-06-14 | 12FS+1.43w | 2017-06-16 | 2017-06-17 | 0.8d | 2017-06-16 | 2017-06-17 | 17.3d |  | Plomero; Acometida hidráulica [15 Un] | 8h | 2,000 | 2,000 |
| 48 | 1.2.4.1.2 | Colocar caja de contador | 0.8d | 2024-06-18 | 2024-06-19 | 18 | 2017-06-21 | 2017-06-22 | 0.8d | 2017-06-21 | 2017-06-22 | 13.3d |  | Ayudante | 8h | 32 | 32 |
| 49 | 1.2.4.1.3 | Realizar instalación hidráulica | 0.71w | 2024-07-10 | 2024-07-15 | 28, 47, 48 | 2017-07-13 | 2017-07-18 | 0.71w | 2017-07-11 | 2017-07-15 | -3.1d | 0d | Instalación hidráulica [0.1%] |  | 320 | 320 |
| 50 | 1.2.4.1.4 | Colocar aparatos sanitarios | 1.6d | 2024-07-01 | 2024-07-03 | 26 | 2017-07-04 | 2017-07-06 | 1.6d | 2017-07-04 | 2017-07-06 | 11.7d |  | Plomero; Ducha [1 Un]; Lavadero [1 Un]; Sanitario [1 Un] | 16h | 1,249 | 1,249 |
| 51 | 1.2.4.1.5 | Instalar tanque de agua | 0.8d | 2024-06-20 | 2024-06-21 | 23 | 2017-06-23 | 2017-06-24 | 0.8d | 2017-06-23 | 2017-06-24 | 20.9d |  | Tanque de agua [1 Un]; Plomero | 8h | 400 | 400 |
| 52 | 1.2.4.2 | **Realizar instalaciones eléctricas** | 9.2d | 2024-07-10 | 2024-07-22 |  | 2017-07-13 | 2017-07-25 | 9.2d | 2017-07-11 | 2017-07-22 | 0d |  |  | 92h | 19,366 | 19,366 |
| 53 | 1.2.4.2.1 | Realizar acometida eléctrica | 1.07w | 2024-07-10 | 2024-07-17 | 26, 49SS | 2017-07-13 | 2017-07-20 | 1.07w | 2017-07-11 | 2017-07-18 | -3.1d | 0d | Acometida eléctrica [30 ml]; Técnico Eléctrico | 60h | 16,260 | 16,260 |
| 54 | 1.2.4.2.2 | Colocar tablero de circuitos | 0.8d | 2024-07-17 | 2024-07-18 | 53 | 2017-07-20 | 2017-07-21 | 0.8d | 2017-07-18 | 2017-07-19 | -3.1d | 0d | Técnico Eléctrico; Tablero 4 circuitos [1 Un] | 8h | 700 | 700 |
| 55 | 1.2.4.2.3 | Colocar salida de toma monofásica y trifásica | 1.6d | 2024-07-18 | 2024-07-19 | 54 | 2017-07-21 | 2017-07-24 | 1.6d | 2017-07-19 | 2017-07-21 | -3.1d | 0d | Tomas y salida PVC [7 Un]; Técnico Eléctrico | 16h | 1,459 | 1,459 |
| 56 | 1.2.4.2.4 | Colocar salida de lámparas | 0.8d | 2024-07-19 | 2024-07-22 | 55 | 2017-07-24 | 2017-07-25 | 0.8d | 2017-07-21 | 2017-07-22 | -3.1d | 0d | Técnico Eléctrico; Lámpara [1 Un] | 8h | 947 | 947 |

| ID | WBS | Task | Type | Duration | Start | Finish | Predecessors | Baseline start | Baseline finish | Baseline duration | Baseline 1 start | Baseline 1 finish | Total slack | Free slack | Calendar | Resources | Work | Cost | Baseline cost |
| --- | --- | --- | --- | --- | --- | --- | --- | --- | --- | --- | --- | --- | --- | --- | --- | --- | --- | --- | --- |
| 57 | 1.3 | **Aseo** |  | 14d | 2024-07-22 | 2024-08-08 |  | 2017-07-25 | 2017-08-11 | 14d | 2017-07-24 | 2017-08-10 | 0d |  |  |  | 112h | 4,520 | 4,520 |
| 58 | 1.3.1 | Definir el alcance de los servicios |  | 1.6d | 2024-07-22 | 2024-07-23 | 32, 40, 44, 49, 50, 51, 56 | 2017-07-25 | 2017-07-26 | 1.6d | 2017-07-24 | 2017-07-25 | -1.9d | 0d | VR2 | Director de proyecto | 16h | 1,120 | 1,120 |
| 59 | 1.3.2 | Contratar los servicios |  | 0.8d | 2024-07-24 | 2024-07-24 | 58 | 2017-07-27 | 2017-07-27 | 0.8d | 2017-07-26 | 2017-07-26 | -1.9d | 0d | VR2 | Director de proyecto; Asistente DP | 16h | 800 | 800 |
| 60 | 1.3.3 | Supervisar el aseo | milestone | 1.43w | 2024-07-25 | 2024-08-08 | 59 | 2017-07-28 | 2017-08-11 | 1.43w | 2017-07-27 | 2017-08-10 | -1.9d | 0d | VR2 | Asistente DP; Aseo [0.1%] | 80h | 2,600 | 2,600 |
| 61 | 2 | **Casa 2 Primera etapa** |  | 68.6d | 2024-08-09 | 2024-11-04 | 1 | 2017-08-14 | 2017-11-15 | 74.2d | 2017-08-11 | 2017-11-15 | 0d |  |  |  | 1238h | 93,434.5 | 93,434.5 |
| 62 | 2.1 | **Preliminares** |  | 22.2d | 2024-08-09 | 2024-09-06 |  | 2017-08-14 | 2017-09-12 | 23.2d | 2017-08-11 | 2017-09-11 | 0d |  |  |  | 232h | 8,788 | 8,788 |
| 63 | 2.1.1 | **Localización y replanteo** |  | 19d | 2024-08-09 | 2024-09-03 |  | 2017-08-14 | 2017-09-08 | 20d | 2017-08-11 | 2017-09-07 | 0d |  |  |  | 200h | 8,660 | 8,660 |
| 64 | 2.1.1.1 | Verificar permisos |  | 1.43w | 2024-08-09 | 2024-08-23 |  | 2017-08-14 | 2017-08-29 | 1.43w | 2017-08-11 | 2017-08-28 | 0d |  | VR2 | Asistente DP | 80h | 2,400 | 2,400 |
| 65 | 2.1.1.2 | Verificar planos constructivos en sitio |  | 0.71w | 2024-08-26 | 2024-08-30 | 64 | 2017-08-30 | 2017-09-05 | 0.71w | 2017-08-29 | 2017-09-04 | 0d |  | VR2 | Arquitecto; Director de proyecto; Ingeniero civil | 120h | 5,800 | 5,800 |
| 66 | 2.1.1.3 | Colocar bodega |  | 2.4d | 2024-08-30 | 2024-09-03 | 65 | 2017-09-05 | 2017-09-08 | 2.4d | 2017-09-04 | 2017-09-07 | 0.2d | 0d |  | Limpieza y bodega [0.1%] |  | 460 | 460 |
| 67 | 2.1.2 | **Limpieza** |  | 3.2d | 2024-09-03 | 2024-09-06 |  | 2017-09-08 | 2017-09-12 | 3.2d | 2017-09-07 | 2017-09-11 | 0.2d |  |  |  | 32h | 128 | 128 |
| 68 | 2.1.2.1 | Nivelar terreno |  | 1.6d | 2024-09-03 | 2024-09-05 | 66 | 2017-09-08 | 2017-09-11 | 1.6d | 2017-09-07 | 2017-09-08 | 0.2d | 0d |  | Ayudante | 16h | 64 | 64 |
| 69 | 2.1.2.2 | Limpiar terreno |  | 1.6d | 2024-09-05 | 2024-09-06 | 68 | 2017-09-11 | 2017-09-12 | 1.6d | 2017-09-08 | 2017-09-11 | 0.2d | 0d |  | Ayudante | 16h | 64 | 64 |
| 70 | 2.2 | **Construcción** |  | 31.6d | 2024-09-06 | 2024-10-16 |  | 2017-09-12 | 2017-10-27 | 36.2d | 2017-09-11 | 2017-10-30 | 0.2d |  |  |  | 894h | 80,126.5 | 80,126.5 |
| 71 | 2.2.1 | **Cimentación** |  | 6.4d | 2024-09-06 | 2024-09-16 |  | 2017-09-12 | 2017-09-20 | 6.4d | 2017-09-11 | 2017-09-19 | 0.2d |  |  |  | 96h | 23,753 | 23,753 |
| 72 | 2.2.1.1 | Realizar excavación |  | 1.6d | 2024-09-06 | 2024-09-09 | 69 | 2017-09-12 | 2017-09-14 | 1.6d | 2017-09-11 | 2017-09-13 | 0.2d | 0d |  | Excavación [0.1%] |  | 963 | 963 |
| 73 | 2.2.1.2 | Colocar concreto |  | 1.6d | 2024-09-09 | 2024-09-11 | 72 | 2017-09-14 | 2017-09-16 | 1.6d | 2017-09-13 | 2017-09-15 | 0.2d | 0d |  | Ayudante; Concreto [8 m3]; Cuadrilla de Obreros [400%] | 32h | 13,160 | 13,160 |
| 74 | 2.2.1.3 | Colocar vigas de amarre |  | 3.2d | 2024-09-11 | 2024-09-16 | 73 | 2017-09-16 | 2017-09-20 | 3.2d | 2017-09-15 | 2017-09-19 | 0.2d | 0d |  | Cuadrilla de Obreros [200%]; Vigas de amarre [2 m3] | 64h | 9,630 | 9,630 |
| 75 | 2.2.2 | **Estructura** |  | 16d | 2024-09-16 | 2024-10-04 |  | 2017-09-20 | 2017-10-10 | 16d | 2017-09-19 | 2017-10-09 | 0.2d |  |  |  | 368h | 20,722.5 | 20,722.5 |
| 76 | 2.2.2.1 | **Realizar muro estructural** |  | 7.2d | 2024-09-16 | 2024-09-24 |  | 2017-09-20 | 2017-09-29 | 7.2d | 2017-09-19 | 2017-09-28 | 0.2d |  |  |  | 144h | 6,606 | 6,606 |
| 77 | 2.2.2.1.1 | Realizar en 1era planta |  | 3.2d | 2024-09-16 | 2024-09-19 | 74 | 2017-09-20 | 2017-09-25 | 3.2d | 2017-09-19 | 2017-09-22 | 0.2d | 0d |  | Ladrillo [100 m2]; Ayudante; Cuadrilla de Obreros [200%] | 64h | 4,988 | 4,988 |
| 78 | 2.2.2.1.2 | Realizar en cubierta |  | 4d | 2024-09-19 | 2024-09-24 | 77 | 2017-09-25 | 2017-09-29 | 4d | 2017-09-22 | 2017-09-28 | 0.2d | 0d |  | Ayudante; Cuadrilla de Obreros [200%]; Teja española [37 m2] | 80h | 1,618 | 1,618 |
| 79 | 2.2.2.2 | Colocar losa de entrepiso |  | 4d | 2024-09-24 | 2024-09-30 | 78 | 2017-09-29 | 2017-10-04 | 4d | 2017-09-28 | 2017-10-03 | 0.2d | 0d |  | Ayudante; Losa maciza [31 m2]; Cuadrilla de Obreros [300%] | 120h | 2,482 | 2,482 |
| 80 | 2.2.2.3 | Realizar escalera |  | 3.2d | 2024-09-30 | 2024-10-03 | 79 | 2017-10-04 | 2017-10-09 | 3.2d | 2017-10-03 | 2017-10-06 | 0.2d | 0d |  | Escaleras [1 m3]; Cuadrilla de Obreros | 32h | 853 | 853 |
| 81 | 2.2.2.4 | Colocar cubierta |  | 4d | 2024-09-24 | 2024-09-30 | 78 | 2017-09-29 | 2017-10-04 | 4d | 2017-09-28 | 2017-10-03 | 5d | 4.8d |  | Cuadrilla de Obreros; Ladrillo [120 m2] | 40h | 5,840 | 5,840 |
| 82 | 2.2.2.5 | Chorrear contra-piso |  | 1.6d | 2024-10-03 | 2024-10-04 | 79, 80 | 2017-10-09 | 2017-10-10 | 1.6d | 2017-10-06 | 2017-10-09 | 0.2d | 0d |  | Contrapiso [30 m2] |  | 3,600 | 3,600 |
| 83 | 2.2.2.6 | Realizar placa del tanque de agua |  | 1.6d | 2024-09-24 | 2024-09-26 | 78 | 2017-09-29 | 2017-10-02 | 1.6d | 2017-09-28 | 2017-09-29 | 15.8d | 0d |  | Ayudante; Plomero; Placa [1.5 m2] | 32h | 1,341.5 | 1,341.5 |

| ID | WBS | Task | Duration | Start | Finish | Predecessors | Baseline start | Baseline finish | Baseline duration | Baseline 1 start | Baseline 1 finish | Total slack | Free slack | Resources | Work | Cost | Baseline cost |
| --- | --- | --- | --- | --- | --- | --- | --- | --- | --- | --- | --- | --- | --- | --- | --- | --- | --- |
| 84 | 2.2.3 | **Acabados** | 9.2d | 2024-10-04 | 2024-10-16 |  | 2017-10-10 | 2017-10-25 | 11.8d | 2017-10-09 | 2017-10-20 | 0.2d |  |  | 328h | 13,484 | 13,484 |
| 85 | 2.2.3.1 | **Colocar mampostería estructural** | 6.8d | 2024-10-04 | 2024-10-14 |  | 2017-10-10 | 2017-10-25 | 11.8d | 2017-10-09 | 2017-10-18 | 0.2d |  |  | 88h | 3,806 | 3,806 |
| 86 | 2.2.3.1.1 | Colocar repello | 1.2d | 2024-10-04 | 2024-10-07 | 81, 82 | 2017-10-10 | 2017-10-12 | 1.2d | 2017-10-09 | 2017-10-11 | 0.2d | 0d | Cuadrilla de Obreros [200%]; Ayudante; Repello [400 m2] | 32h | 2,552 | 2,552 |
| 87 | 2.2.3.1.2 | Afinar filos | 1.6d | 2024-10-07 | 2024-10-09 | 86 | 2017-10-12 | 2017-10-13 | 1.6d | 2017-10-11 | 2017-10-12 | 0.2d | 0d | Ayudante | 16h | 64 | 64 |
| 88 | 2.2.3.1.3 | Aplicar pintura | 0.71w | 2024-10-09 | 2024-10-14 | 87 | 2017-10-13 | 2017-10-25 | 0.71w | 2017-10-12 | 2017-10-18 | 0.2d | 0d | Pintor; Pintura [30 m2] | 40h | 1,190 | 1,190 |
| 89 | 2.2.3.2 | **Colocar pisos y enchapes** | 8d | 2024-10-07 | 2024-10-16 |  | 2017-10-12 | 2017-10-21 | 8d | 2017-10-11 | 2017-10-20 | 3.4d |  |  | 56h | 2,348 | 2,348 |
| 90 | 2.2.3.2.1 | Colocar enchape baño | 0.8d | 2024-10-07 | 2024-10-08 | 86 | 2017-10-12 | 2017-10-12 | 0.8d | 2017-10-11 | 2017-10-11 | 22d |  | Pintor; Enchape [4 m2] | 8h | 264 | 264 |
| 91 | 2.2.3.2.2 | Alistar piso | 1.6d | 2024-10-10 | 2024-10-12 | 88SS+1.6d | 2017-10-16 | 2017-10-18 | 1.6d | 2017-10-14 | 2017-10-17 | 0.2d | 0d | Ayudante | 16h | 64 | 64 |
| 92 | 2.2.3.2.3 | Instalar piso | 3.2d | 2024-10-12 | 2024-10-16 | 91 | 2017-10-18 | 2017-10-21 | 3.2d | 2017-10-17 | 2017-10-20 | 0.2d |  | Cuadrilla de Obreros; Porcelanato [62 m2] | 32h | 2,020 | 2,020 |
| 93 | 2.2.3.3 | **Instalar piso** | 8d | 2024-10-07 | 2024-10-16 |  | 2017-10-12 | 2017-10-21 | 8d | 2017-10-11 | 2017-10-20 | 0.2d |  |  | 136h | 5,370 | 5,370 |
| 94 | 2.2.3.3.1 | **Realizar estructura metálica** | 2.4d | 2024-10-07 | 2024-10-09 |  | 2017-10-12 | 2017-10-14 | 2.4d | 2017-10-11 | 2017-10-13 | 0.2d |  |  | 48h | 1,578 | 1,578 |
| 95 | 2.2.3.3.1.1 | Armar marcos de puertas | 1.6d | 2024-10-07 | 2024-10-09 | 86 | 2017-10-12 | 2017-10-13 | 1.6d | 2017-10-11 | 2017-10-12 | 19.6d | 0d | Carpintero; Marcos de puertas [6 Un] | 16h | 944 | 944 |
| 96 | 2.2.3.3.1.2 | Colocar puerta entrada y patio | 0.8d | 2024-10-09 | 2024-10-09 | 95 | 2017-10-13 | 2017-10-14 | 0.8d | 2017-10-12 | 2017-10-13 | 19.6d | 0d | Carpintero; Puerta principales [1 Un] | 8h | 314 | 314 |
| 97 | 2.2.3.3.1.3 | Armar ventanas | 2.4d | 2024-10-07 | 2024-10-09 | 86 | 2017-10-12 | 2017-10-14 | 2.4d | 2017-10-11 | 2017-10-13 | 0.2d | 0d | Cuadrilla de Obreros; Ventanas [2.5 m2] | 24h | 320 | 320 |
| 98 | 2.2.3.3.2 | **Realizar estructura madera** | 6.4d | 2024-10-09 | 2024-10-16 |  | 2017-10-13 | 2017-10-21 | 6.4d | 2017-10-12 | 2017-10-20 | 2.6d |  |  | 88h | 3,792 | 3,792 |
| 99 | 2.2.3.3.2.1 | Colocar puerta de interiores | 0.8d | 2024-10-09 | 2024-10-09 | 95 | 2017-10-13 | 2017-10-14 | 0.8d | 2017-10-12 | 2017-10-13 | 19.6d | 0d | Ayudante; Puertas interiores [4 Un] | 8h | 512 | 512 |
| 100 | 2.2.3.3.2.2 | Armar closet | 0.71w | 2024-10-11 | 2024-10-16 | 97FS+1.6d | 2017-10-17 | 2017-10-21 | 0.71w | 2017-10-16 | 2017-10-20 | 0.2d |  | Ayudante; Carpintero; Closet [4 m2] | 80h | 3,280 | 3,280 |
| 101 | 2.2.3.4 | **Colocar vidrios y cerraduras** | 3.2d | 2024-10-09 | 2024-10-14 |  | 2017-10-14 | 2017-10-19 | 3.2d | 2017-10-13 | 2017-10-18 | 2.6d |  |  | 48h | 1,960 | 1,960 |
| 102 | 2.2.3.4.1 | Colocar cerradura de entrada y patio | 0.8d | 2024-10-09 | 2024-10-10 | 96 | 2017-10-14 | 2017-10-16 | 0.8d | 2017-10-13 | 2017-10-14 | 19.6d |  | Cerraduras principales [2 Un]; Carpintero | 8h | 564 | 564 |
| 103 | 2.2.3.4.2 | Colocar cerradura de puertas interiores | 0.8d | 2024-10-09 | 2024-10-10 | 96, 99 | 2017-10-14 | 2017-10-16 | 0.8d | 2017-10-13 | 2017-10-14 | 19.6d |  | Ayudante; Cerraduras interiores [4 Un] | 8h | 312 | 312 |
| 104 | 2.2.3.4.3 | Colocar vidrios | 3.2d | 2024-10-09 | 2024-10-14 | 97 | 2017-10-14 | 2017-10-19 | 3.2d | 2017-10-13 | 2017-10-18 | 2.6d |  | Cuadrilla de Obreros; Vidrios [4 m2] | 32h | 1,084 | 1,084 |
| 105 | 2.2.4 | **Instalaciones domiciliarias** | 21.59d | 2024-09-19 | 2024-10-16 |  | 2017-09-25 | 2017-10-27 | 26.59d | 2017-09-22 | 2017-10-30 | 0.6d |  |  | 102h | 22,167 | 22,167 |
| 106 | 2.2.4.1 | **Realizar instalaciones hidrosanitarias** | 21.59d | 2024-09-19 | 2024-10-16 |  | 2017-09-25 | 2017-10-27 | 26.59d | 2017-09-22 | 2017-10-23 | 0.6d |  |  | 40h | 4,001 | 4,001 |
| 107 | 2.2.4.1.1 | Realizar acometida hidráulica | 0.8d | 2024-09-19 | 2024-09-20 | 72FS+1.43w | 2017-09-25 | 2017-09-26 | 0.8d | 2017-09-22 | 2017-09-25 | 19.39d | 18.79d | Plomero; Acometida hidráulica [15 Un] | 8h | 2,000 | 2,000 |
| 108 | 2.2.4.1.2 | Colocar caja de contador | 0.8d | 2024-09-24 | 2024-09-25 | 78 | 2017-09-29 | 2017-09-30 | 0.8d | 2017-09-28 | 2017-09-29 | 15.4d | 14.8d | Ayudante | 8h | 32 | 32 |
| 109 | 2.2.4.1.3 | Realizar instalación hidráulica | 2d | 2024-10-14 | 2024-10-16 | 88, 107, 108 | 2017-10-25 | 2017-10-27 | 2d | 2017-10-18 | 2017-10-23 | 0.6d |  | Instalación hidráulica [0.1%] |  | 320 | 320 |
| 110 | 2.2.4.1.4 | Colocar aparatos sanitarios | 1.6d | 2024-10-07 | 2024-10-09 | 86 | 2017-10-12 | 2017-10-13 | 1.6d | 2017-10-11 | 2017-10-12 | 6.6d |  | Plomero; Ducha [1 Un]; Lavadero [1 Un]; Sanitario [1 Un] | 16h | 1,249 | 1,249 |
| 111 | 2.2.4.1.5 | Instalar tanque de agua | 0.8d | 2024-09-26 | 2024-09-27 | 83 | 2017-10-02 | 2017-10-03 | 0.8d | 2017-09-29 | 2017-10-02 | 15.8d |  | Tanque de agua [1 Un]; Plomero | 8h | 400 | 400 |

| ID | WBS | Task | Type | Duration | Start | Finish | Predecessors | Baseline start | Baseline finish | Baseline duration | Baseline 1 start | Baseline 1 finish | Total slack | Free slack | Calendar | Resources | Work | Cost | Baseline cost |
| --- | --- | --- | --- | --- | --- | --- | --- | --- | --- | --- | --- | --- | --- | --- | --- | --- | --- | --- | --- |
| 112 | 2.2.4.2 | **Realizar instalaciones eléctricas** |  | 6.2d | 2024-10-07 | 2024-10-15 |  | 2017-10-12 | 2017-10-19 | 6.2d | 2017-10-18 | 2017-10-30 | 2d |  |  |  | 62h | 18,166 | 18,166 |
| 113 | 2.2.4.2.1 | Realizar acometida eléctrica |  | 3d | 2024-10-07 | 2024-10-10 | 86 | 2017-10-12 | 2017-10-16 | 3d | 2017-10-18 | 2017-10-25 | 2d | 0d |  | Acometida eléctrica [30 ml]; Técnico Eléctrico | 30h | 15,060 | 15,060 |
| 114 | 2.2.4.2.2 | Colocar tablero de circuitos |  | 0.8d | 2024-10-10 | 2024-10-11 | 113 | 2017-10-16 | 2017-10-17 | 0.8d | 2017-10-25 | 2017-10-26 | 2d | 0d |  | Técnico Eléctrico; Tablero 4 circuitos [1 Un] | 8h | 700 | 700 |
| 115 | 2.2.4.2.3 | Colocar salida de toma monofásica y trifásica |  | 1.6d | 2024-10-11 | 2024-10-14 | 114 | 2017-10-17 | 2017-10-18 | 1.6d | 2017-10-26 | 2017-10-27 | 2d | 0d |  | Tomas y salida PVC [7 Un]; Técnico Eléctrico | 16h | 1,459 | 1,459 |
| 116 | 2.2.4.2.4 | Colocar salida de lámparas |  | 0.8d | 2024-10-14 | 2024-10-15 | 115 | 2017-10-18 | 2017-10-19 | 0.8d | 2017-10-27 | 2017-10-30 | 2d |  |  | Técnico Eléctrico; Lámpara [1 Un] | 8h | 947 | 947 |
| 117 | 2.3 | **Aseo** |  | 14.6d | 2024-10-17 | 2024-11-04 |  | 2017-10-27 | 2017-11-15 | 14.8d | 2017-10-30 | 2017-11-15 | 0d |  |  |  | 112h | 4,520 | 4,520 |
| 118 | 2.3.1 | Definir el alcance de los servicios |  | 1.6d | 2024-10-17 | 2024-10-18 | 92, 100, 104, 109, 110, 111, 116 | 2017-10-27 | 2017-10-31 | 1.6d | 2017-10-30 | 2017-10-31 | 0d |  | VR2 | Director de proyecto | 16h | 1,120 | 1,120 |
| 119 | 2.3.2 | Contratar los servicios |  | 0.8d | 2024-10-21 | 2024-10-21 | 118 | 2017-10-31 | 2017-11-01 | 0.8d | 2017-11-01 | 2017-11-01 | 0d |  | VR2 | Director de proyecto; Asistente DP | 16h | 800 | 800 |
| 120 | 2.3.3 | Supervisar el aseo | milestone | 1.43w | 2024-10-22 | 2024-11-04 | 119 | 2017-11-01 | 2017-11-15 | 1.43w | 2017-11-02 | 2017-11-15 | 0d |  | VR2 | Asistente DP; Aseo [0.1%] | 80h | 2,600 | 2,600 |
